Schedule from MS Project, 2010-02-01 to 2010-05-13, costs in лв..

## Calendars

- Standard: Mon-Fri 08:00-12:00, 13:00-17:00; Sat-Sun off.

## Resources

| Resource | Rate |
| --- | --- |
| Яна Янкова | 75 |
| Боян Бъчваров | 75 |
| Елеонора Янева | 75 |
| Таня Вряшкова | 75 |
| Анна Ангелова | 75 |
| Иван Василев | 75 |
| Надежда Тасева | 75 |
| Ана Серафимова | 75 |
| Велизар Ангелов | 75 |

## Schedule

| ID | WBS | Task | Duration | Start | Finish | Predecessors | Total slack | Free slack | Constraint | Resources | Work | Cost |
| --- | --- | --- | --- | --- | --- | --- | --- | --- | --- | --- | --- | --- |
| 1 | 1 | **Клиентски модул (уеб сайт) - C** | 43.5d | 2010-02-01 | 2010-04-01 |  | 10d |  |  |  | 848h | 63,600 |
| 2 | 1.1 | **Обща функционалност – CF** | 26d | 2010-02-01 | 2010-03-08 |  | 10d | 17.5d |  |  | 328h | 24,600 |
| 3 | 1.1.1 | **Създаване на обща бизнес логика – CF_BL** | 8d | 2010-02-01 | 2010-02-10 |  | 10d | 0d |  |  | 64h | 4,800 |
| 4 | 1.1.1.1 | Конфигурационен клас - CF_BLCfg | 4d | 2010-02-01 | 2010-02-04 |  | 10d | 0d | start no earlier than 2010-02-01 | Елеонора Янева | 32h | 2,400 |
| 5 | 1.1.1.2 | Клас за достъп до данните - CF_BLDAC | 4d | 2010-02-05 | 2010-02-10 | 4 | 10d |  |  | Елеонора Янева | 32h | 2,400 |
| 6 | 1.1.2 | Генерален пакет съхранени процедури - CF_SP | 6d | 2010-02-11 | 2010-02-18 | 83 | 11d | 0d |  | Велизар Ангелов; Елеонора Янева | 96h | 7,200 |
| 7 | 1.1.3 | **Създаване на обща презентационна логика – CF_UI** | 13d | 2010-02-01 | 2010-02-17 |  | 28.5d | 1d |  |  | 72h | 5,400 |
| 8 | 1.1.3.1 | Създаване на стилове – CF_UIS | 4d | 2010-02-01 | 2010-02-04 |  | 37.5d |  | start no earlier than 2010-02-01 | Таня Вряшкова | 32h | 2,400 |
| 9 | 1.1.3.2 | Създаване на Master–page – CF_UIM | 5d | 2010-02-11 | 2010-02-17 | 3 | 28.5d |  | start no earlier than 2010-02-01 | Таня Вряшкова | 40h | 3,000 |
| 10 | 1.1.4 | Тестване – CF_T | 7d | 2010-02-19 | 2010-03-01 | 6, 7 | 27.5d | 0d | start no earlier than 2010-02-01 | Ана Серафимова | 56h | 4,200 |
| 11 | 1.1.5 | Документиране - CF_D | 5d | 2010-03-02 | 2010-03-08 | 10 | 27.5d |  | start no earlier than 2010-02-01 | Ана Серафимова | 40h | 3,000 |
| 12 | 1.2 | **Модул Екскурзии – CE** | 32d | 2010-02-11 | 2010-03-26 | 3 | 12d | 3.5d |  |  | 272h | 20,400 |
| 13 | 1.2.1 | **Модул Избиране на екскурзии – CЕS** | 20d | 2010-02-11 | 2010-03-10 |  | 12d | 0d |  |  | 88h | 6,600 |
| 14 | 1.2.1.1 | Потребителски интерфейс – CES_UI | 5d | 2010-02-11 | 2010-02-17 |  | 12d | 0d | start no earlier than 2010-02-01 | Надежда Тасева | 40h | 3,000 |
| 15 | 1.2.1.2 | Бизнес логика – CES_BL | 6d | 2010-03-03 | 2010-03-10 | 14 | 12d |  | finish no earlier than 2010-02-05 | Надежда Тасева | 48h | 3,600 |
| 16 | 1.2.2 | **Модул Резервации – CЕR** | 9d | 2010-02-18 | 2010-03-02 |  | 18d | 6d |  |  | 72h | 5,400 |
| 17 | 1.2.2.1 | Потребителски интерфейс – CES_UI | 3d | 2010-02-18 | 2010-02-22 |  | 18d | 0d | start no earlier than 2010-02-01 | Надежда Тасева | 24h | 1,800 |
| 18 | 1.2.2.2 | Бизнес логика – CER_BL | 6d | 2010-02-23 | 2010-03-02 | 17 | 18d |  | start no earlier than 2010-02-01 | Надежда Тасева | 48h | 3,600 |
| 19 | 1.2.3 | Пакет съхранени процедури - Екскурзии и резервации – CE_SP | 4d | 2010-03-01 | 2010-03-04 | 6 | 16d | 4d | start no earlier than 2010-02-01 | Елеонора Янева | 32h | 2,400 |
| 20 | 1.2.4 | Тестване – CE_T | 5d | 2010-03-15 | 2010-03-19 | 19, 13, 16 | 13.5d | 0d | start no earlier than 2010-02-01 | Анна Ангелова | 40h | 3,000 |
| 21 | 1.2.5 | Документиране – CE_D | 5d | 2010-03-22 | 2010-03-26 | 20 | 13.5d |  | start no earlier than 2010-02-01 | Таня Вряшкова | 40h | 3,000 |
| 22 | 1.3 | **Модул Плащания - CP** | 29.5d | 2010-02-18 | 2010-03-31 | 3 | 11d | 1d |  |  | 96h | 7,200 |
| 23 | 1.3.1 | Потребителски интерфейс – CP_UI | 3d | 2010-02-18 | 2010-02-22 |  | 16d | 0d | start no earlier than 2010-02-01 | Таня Вряшкова | 24h | 1,800 |
| 24 | 1.3.2 | Бизнес логика – CP_BL | 3d | 2010-03-04 | 2010-03-08 | 23 | 16d | 5d | start no earlier than 2010-02-01 | Таня Вряшкова | 24h | 1,800 |
| 25 | 1.3.3 | Пакет съхранени процедури - Плащания – CP_SP | 2d | 2010-03-12 | 2010-03-15 | 6 | 11d | 0d |  | Елеонора Янева | 16h | 1,200 |
| 26 | 1.3.4 | Тестване – CP_T | 2d | 2010-03-17 | 2010-03-18 | 24, 25 | 11d | 0d |  | Ана Серафимова | 16h | 1,200 |
| 27 | 1.3.5 | Документиране – CP_D | 2d | 2010-03-29 | 2010-03-31 | 26 | 11d |  |  | Ана Серафимова | 16h | 1,200 |

| ID | WBS | Task | Type | Duration | Start | Finish | Predecessors | Total slack | Free slack | Constraint | Resources | Work | Cost |
| --- | --- | --- | --- | --- | --- | --- | --- | --- | --- | --- | --- | --- | --- |
| 28 | 1.4 | **Модул Реклами - Cadv** |  | 21.5d | 2010-02-23 | 2010-03-24 | 3 | 16d | 6d |  |  | 96h | 7,200 |
| 29 | 1.4.1 | Потребителски интерфейс – Cadv_UI |  | 3d | 2010-02-23 | 2010-02-25 |  | 16d | 0d |  | Таня Вряшкова | 24h | 1,800 |
| 30 | 1.4.2 | Бизнес логика – CAdv_BL |  | 3d | 2010-03-09 | 2010-03-11 | 29 | 16d | 0d |  | Таня Вряшкова | 24h | 1,800 |
| 31 | 1.4.3 | Пакет съхранени процедури - Реклами – Cadv_SP |  | 2d | 2010-03-10 | 2010-03-11 | 6 | 16d | 0d | start no earlier than 2010-03-03 | Елеонора Янева | 16h | 1,200 |
| 32 | 1.4.4 | Тестване – Cadv_T |  | 2d | 2010-03-15 | 2010-03-16 | 31, 30 | 16d | 0d |  | Ана Серафимова | 16h | 1,200 |
| 33 | 1.4.5 | Документиране – Cadv_D |  | 2d | 2010-03-22 | 2010-03-24 | 32 | 16d |  | start no earlier than 2010-02-01 | Ана Серафимова | 16h | 1,200 |
| 34 | 1.5 | **Модул Информация - ACP** |  | 22.5d | 2010-03-02 | 2010-04-01 |  | 10d | 0d |  |  | 32h | 2,400 |
| 35 | 1.5.1 | Потребителски интерфейс – Cinf_UI |  | 4h | 2010-03-19 | 2010-03-19 | 3 | 10d | 0d |  | Ана Серафимова; Елеонора Янева | 8h | 600 |
| 36 | 1.5.2 | Бизнес логика – Cinf_BL |  | 4h | 2010-03-19 | 2010-03-19 | 35 | 10d | 0d |  | Таня Вряшкова; Елеонора Янева | 8h | 600 |
| 37 | 1.5.3 | Пакет съхранени процедури - Информация – Cinf_SP |  | 4h | 2010-03-02 | 2010-03-02 | 6 | 23.5d | 13.5d |  | Велизар Ангелов | 4h | 300 |
| 38 | 1.5.4 | Тестване – Cinf_T |  | 4h | 2010-03-22 | 2010-03-22 | 37, 36 | 10d | 0d |  | Ана Серафимова | 4h | 300 |
| 39 | 1.5.5 | Документиране – Cinf_D |  | 4h | 2010-04-01 | 2010-04-01 | 38 | 10d |  |  | Таня Вряшкова; Ана Серафимова | 8h | 600 |
| 40 | 1.6 | **Система за нотификация – CN** |  | 14d | 2010-03-12 | 2010-03-31 | 6, 3 | 10.5d | 0.5d |  |  | 24h | 1,800 |
| 41 | 1.6.1 | Бизнес логика – CN _BL |  | 1d | 2010-03-12 | 2010-03-12 | 3 | 13d | 0d |  | Таня Вряшкова | 8h | 600 |
| 42 | 1.6.2 | Пакет съхранени процедури - Нотификация – CN _SP |  | 1d | 2010-03-15 | 2010-03-15 | 41 | 13d | 0d | start no earlier than 2010-02-01 | Таня Вряшкова | 8h | 600 |
| 43 | 1.6.3 | Тестване – CN _T |  | 4h | 2010-03-19 | 2010-03-19 | 42 | 11d | 0d |  | Ана Серафимова | 4h | 300 |
| 44 | 1.6.4 | Документиране – CN _D |  | 4h | 2010-03-31 | 2010-03-31 | 43 | 10.5d |  |  | Ана Серафимова | 4h | 300 |
| 45 | 1.7 | Оперативност и съответствие със спецификацията | milestone | 0d | 2010-04-01 | 2010-04-01 | 34, 40, 28, 22, 12, 2 | 10d |  | start no earlier than 2010-04-01 |  |  |  |
| 46 | 2 | **Вътрешнофирмен (административен) модул** |  | 53.5d | 2010-02-01 | 2010-04-15 |  | 0d |  |  |  | 952h | 71,400 |
| 47 | 2.1 | **Обща функционалност – AF** |  | 40.5d | 2010-02-01 | 2010-03-29 |  | 0d |  |  |  | 280h | 21,000 |
| 48 | 2.1.1 | **Създаване на обща бизнес логика – CF_BL** |  | 8d | 2010-02-01 | 2010-02-10 |  | 0d |  |  |  | 64h | 4,800 |
| 49 | 2.1.1.1 | Конфигурационен клас - CF_BLCfg |  | 4d | 2010-02-01 | 2010-02-04 |  | 0d |  | start no earlier than 2010-02-01 | Иван Василев | 32h | 2,400 |
| 50 | 2.1.1.2 | Клас за достъп до данните - CF_BLDAC |  | 4d | 2010-02-05 | 2010-02-10 | 49 | 0d |  |  | Иван Василев | 32h | 2,400 |
| 51 | 2.1.2 | Генерален пакет съхранени процедури - CF_SP |  | 6d | 2010-02-19 | 2010-02-26 | 83 | 0.5d | 0d |  | Боян Бъчваров; Елеонора Янева | 96h | 7,200 |

| ID | WBS | Task | Type | Duration | Start | Finish | Predecessors | Total slack | Free slack | Constraint | Resources | Work | Cost |
| --- | --- | --- | --- | --- | --- | --- | --- | --- | --- | --- | --- | --- | --- |
| 52 | 2.1.3 | **Създаване на обща презентационна логика – AF _UI** |  | 19d | 2010-02-05 | 2010-03-03 |  | 15d | 0d |  |  | 64h | 4,800 |
| 53 | 2.1.3.1 | Създаване на Master–page – AF _UIM |  | 4d | 2010-02-05 | 2010-02-10 |  | 30d |  | start no earlier than 2010-02-01 | Таня Вряшкова | 32h | 2,400 |
| 54 | 2.1.3.2 | Създаване на стилове – AF _UIS |  | 4d | 2010-02-26 | 2010-03-03 |  | 15d |  | start no earlier than 2010-02-01 | Таня Вряшкова | 32h | 2,400 |
| 55 | 2.1.4 | Тестване – AF _T |  | 4d | 2010-03-09 | 2010-03-12 | 52, 51, 48 | 15d | 0d | start no earlier than 2010-02-01 | Ана Серафимова | 32h | 2,400 |
| 56 | 2.1.5 | Документиране - AF _D |  | 3d | 2010-03-24 | 2010-03-29 | 55 | 13d |  | start no earlier than 2010-02-01 | Ана Серафимова | 24h | 1,800 |
| 57 | 2.2 | **Модул Управление на екскурзиите – AE** |  | 30d | 2010-02-18 | 2010-03-31 |  | 10.5d |  |  |  | 176h | 13,200 |
| 58 | 2.2.1 | Потребителски интерфейс – AE_UI |  | 4d | 2010-02-18 | 2010-02-23 | 48 | 10.5d | 0d | start no earlier than 2010-02-01 | Иван Василев | 32h | 2,400 |
| 59 | 2.2.2 | Бизнес логика – AE_BL |  | 6d | 2010-03-12 | 2010-03-19 | 58 | 10.5d | 0d | start no earlier than 2010-02-01 | Иван Василев | 48h | 3,600 |
| 60 | 2.2.3 | Пакет съхранени процедури - Управление на екскурзиите – AE_SP |  | 4d | 2010-03-09 | 2010-03-12 | 51 | 15.5d | 5d | start no earlier than 2010-02-01 | Яна Янкова | 32h | 2,400 |
| 61 | 2.2.4 | Тестване – AE_T |  | 4d | 2010-03-22 | 2010-03-25 | 60, 59 | 10.5d | 0d | start no earlier than 2010-02-01 | Анна Ангелова | 32h | 2,400 |
| 62 | 2.2.5 | Документиране – AE_D |  | 4d | 2010-03-26 | 2010-03-31 | 61 | 10.5d |  | start no earlier than 2010-02-01 | Анна Ангелова | 32h | 2,400 |
| 63 | 2.3 | **Модул Управление на клиентски досиета – ACP** |  | 36.5d | 2010-02-24 | 2010-04-15 |  | 0d |  |  |  | 152h | 11,400 |
| 64 | 2.3.1 | Потребителски интерфейс – ACP_UI |  | 4d | 2010-02-24 | 2010-03-01 | 48 | 0d |  | start no earlier than 2010-02-01 | Иван Василев | 32h | 2,400 |
| 65 | 2.3.2 | Бизнес логика – ACP_BL |  | 5d | 2010-03-31 | 2010-04-06 | 64 | 0d |  | start no earlier than 2010-02-01 | Иван Василев | 40h | 3,000 |
| 66 | 2.3.3 | Пакет съхранени процедури - Управление на клиентски досиета – ACP_SP |  | 4d | 2010-03-15 | 2010-03-18 | 51 | 13d |  | start no earlier than 2010-02-01 | Яна Янкова | 32h | 2,400 |
| 67 | 2.3.4 | Тестване – ACP_T |  | 3d | 2010-04-07 | 2010-04-12 | 66, 65 | 0d |  |  | Ана Серафимова | 24h | 1,800 |
| 68 | 2.3.5 | Документиране – ACP_D |  | 3d | 2010-04-12 | 2010-04-15 | 67 | 0d |  |  | Ана Серафимова | 24h | 1,800 |
| 69 | 2.4 | **Статистически Модул – AS** |  | 31d | 2010-02-11 | 2010-03-25 |  | 14.5d |  |  |  | 224h | 16,800 |
| 70 | 2.4.1 | Потребителски интерфейс – AS_UI |  | 5d | 2010-02-11 | 2010-02-17 | 48 | 14.5d | 0d | start no earlier than 2010-02-01 | Иван Василев | 40h | 3,000 |
| 71 | 2.4.2 | Бизнес логика – AS_BL |  | 8d | 2010-03-02 | 2010-03-11 | 70 | 14.5d | 0d | start no earlier than 2010-02-01 | Иван Василев | 64h | 4,800 |
| 72 | 2.4.3 | Пакет съхранени процедури - Статистически модул – AS_SP |  | 5d | 2010-03-02 | 2010-03-08 | 51 | 17.5d | 3d | start no earlier than 2010-02-01 | Яна Янкова | 40h | 3,000 |
| 73 | 2.4.4 | Тестване – AS_T |  | 6d | 2010-03-12 | 2010-03-19 | 72, 71 | 14.5d | 0d | start no earlier than 2010-02-01 | Надежда Тасева | 48h | 3,600 |
| 74 | 2.4.5 | Документиране –AS_D |  | 4d | 2010-03-22 | 2010-03-25 | 73 | 14.5d |  | start no earlier than 2010-02-01 | Надежда Тасева | 32h | 2,400 |
| 75 | 2.5 | **Модул Връзки с обществеността – APR** |  | 33d | 2010-03-01 | 2010-04-14 |  | 0.5d |  |  |  | 120h | 9,000 |
| 76 | 2.5.1 | Потребителски интерфейс – APR _UI |  | 3d | 2010-03-01 | 2010-03-03 | 48 | 1.5d | 0d | start no earlier than 2010-02-01 | Боян Бъчваров | 24h | 1,800 |
| 77 | 2.5.2 | Бизнес логика – APR _BL |  | 3d | 2010-03-04 | 2010-03-08 | 76 | 1.5d | 1d | start no earlier than 2010-02-01 | Боян Бъчваров | 24h | 1,800 |
| 78 | 2.5.3 | Пакет съхранени процедури - Връзки с обществеността – APR _SP |  | 3d | 2010-03-05 | 2010-03-09 | 51 | 0.5d | 0d | start no earlier than 2010-02-01 | Елеонора Янева | 24h | 1,800 |
| 79 | 2.5.4 | Тестване – APR _T |  | 3d | 2010-03-10 | 2010-03-12 | 78, 77 | 0.5d | 0d | start no earlier than 2010-02-01 | Анна Ангелова | 24h | 1,800 |
| 80 | 2.5.5 | Документиране –APR _D |  | 3d | 2010-04-12 | 2010-04-14 | 79 | 0.5d |  | start no earlier than 2010-02-01 | Анна Ангелова | 24h | 1,800 |
| 81 | 2.6 | Оперативност и съответствие със спецификацията | milestone | 0d | 2010-04-15 | 2010-04-15 | 75, 63, 57, 69, 47 | 0d |  | start no earlier than 2010-04-01 |  |  |  |

| ID | WBS | Task | Type | Duration | Start | Finish | Predecessors | Total slack | Free slack | Constraint | Resources | Work | Cost |
| --- | --- | --- | --- | --- | --- | --- | --- | --- | --- | --- | --- | --- | --- |
| 82 | 3 | **База данни – DB** |  | 50d | 2010-02-01 | 2010-04-09 |  | 0.5d | 3.5d |  |  | 544h | 40,800 |
| 83 | 3.1 | **Анализ и проектиране – DBAP** |  | 8d | 2010-02-01 | 2010-02-10 |  | 0.5d | 0d |  |  | 128h | 9,600 |
| 84 | 3.1.1 | Е/R модел на базата от данни – DBAPER |  | 5d | 2010-02-01 | 2010-02-05 |  | 0.5d | 0d | start no earlier than 2010-02-01 | Яна Янкова; Боян Бъчваров | 80h | 6,000 |
| 85 | 3.1.2 | Схема на базата от данни – DBAPSch |  | 3d | 2010-02-08 | 2010-02-10 | 84 | 0.5d |  |  | Яна Янкова; Велизар Ангелов | 48h | 3,600 |
| 86 | 3.2 | Реализация на базата от данни – DBR |  | 5d | 2010-02-11 | 2010-02-17 | 83 | 3.5d | 0d |  | Яна Янкова; Боян Бъчваров | 80h | 6,000 |
| 87 | 3.3 | Създаване общата програмна логика – DBL |  | 7d | 2010-02-19 | 2010-03-01 | 86 | 3.5d | 0d | finish no earlier than 2010-02-11 | Яна Янкова; Велизар Ангелов | 112h | 8,400 |
| 88 | 3.4 | Тестване – DB_T |  | 7d | 2010-03-22 | 2010-03-30 | 87 | 3.5d | 0d |  | Велизар Ангелов; Иван Василев | 112h | 8,400 |
| 89 | 3.5 | Документиране – DB_D |  | 7d | 2010-04-01 | 2010-04-09 | 88 | 3.5d | 0d |  | Велизар Ангелов; Анна Ангелова | 112h | 8,400 |
| 90 | 3.6 | Оперативност и съответствие със спецификацията | milestone | 0d | 2010-04-09 | 2010-04-09 | 89 | 3.5d |  | start no earlier than 2010-04-01 |  |  |  |
| 91 | 4 | **Тестване – Т** |  | 13d | 2010-04-15 | 2010-05-04 | 1, 46, 82 | 0d |  |  |  | 176h | 13,200 |
| 92 | 4.1 | Установяване на подходите за тестване – T_A |  | 1d | 2010-04-15 | 2010-04-16 |  | 0d |  | finish no earlier than 2010-02-11 | Иван Василев; Надежда Тасева | 16h | 1,200 |
| 93 | 4.2 | Установяване на изискванията към работната среда – T_ER |  | 1d | 2010-04-16 | 2010-04-19 | 92 | 0d |  |  | Иван Василев; Надежда Тасева | 16h | 1,200 |
| 94 | 4.3 | Съставяне на план за тестване – T_P |  | 3d | 2010-04-19 | 2010-04-22 | 93 | 0d |  |  | Иван Василев; Надежда Тасева | 48h | 3,600 |
| 95 | 4.4 | Извършване на тестовете – T_E |  | 4d | 2010-04-22 | 2010-04-28 | 94 | 0d |  |  | Иван Василев; Надежда Тасева | 64h | 4,800 |
| 96 | 4.5 | Документиране – T_D |  | 4d | 2010-04-28 | 2010-05-04 | 95 | 0d |  |  | Надежда Тасева | 32h | 2,400 |
| 97 | 4.6 | Извършено по план цялостно тестване на системата | milestone | 0d | 2010-05-04 | 2010-05-04 | 96 | 0d |  | start no earlier than 2010-04-01 |  |  |  |
| 98 | 5 | **Документиране – D** |  | 20d | 2010-04-15 | 2010-05-13 |  | 0d |  |  |  | 96h | 7,200 |
| 99 | 5.1 | **Разработване на ръководства – DR** |  | 4d | 2010-04-15 | 2010-04-21 |  | 12d |  |  |  | 64h | 4,800 |
| 100 | 5.1.1 | Ръководство за администриране – DRA |  | 4d | 2010-04-15 | 2010-04-21 | 46, 1 | 12d | 0d |  | Анна Ангелова | 32h | 2,400 |
| 101 | 5.1.2 | Ръководство за употреба – DRU |  | 4d | 2010-04-15 | 2010-04-21 | 1, 46 | 12d | 0d |  | Ана Серафимова | 32h | 2,400 |
| 102 | 5.1.3 | Създадени пълни потребителски ръководства | milestone | 0d | 2010-04-21 | 2010-04-21 | 101, 100 | 12d |  | start no earlier than 2010-04-01 |  |  |  |
| 103 | 5.2 | Съставяне на цялостен пакет документи – DSp |  | 4d | 2010-05-07 | 2010-05-13 | 10, 105, 99, 91 | 0d |  |  | Анна Ангелова | 32h | 2,400 |
| 104 | 5.3 | Съставен пълен пакет документи | milestone | 0d | 2010-05-13 | 2010-05-13 | 103 | 0d |  | start no earlier than 2010-04-01 |  |  |  |
| 105 | 6 | **Инсталиране - I** |  | 3d | 2010-05-04 | 2010-05-07 | 91 | 0d |  |  |  | 32h | 2,400 |
| 106 | 6.1 | Създаване на скриптове за създаване на базата от данни – IDB |  | 1d | 2010-05-04 | 2010-05-05 | 82 | 1d |  |  | Велизар Ангелов | 8h | 600 |
| 107 | 6.2 | Създаване на инсталатор за приложението – IАS |  | 2d | 2010-05-04 | 2010-05-06 | 1, 46 | 0d |  |  | Боян Бъчваров | 16h | 1,200 |
| 108 | 6.3 | Документиране – I_D |  | 1d | 2010-05-06 | 2010-05-07 | 107, 106 | 0d |  |  | Анна Ангелова | 8h | 600 |
| 109 | 6.4 | Създадени работещи инсталатори | milestone | 0d | 2010-05-07 | 2010-05-07 | 108 | 0d |  | start no earlier than 2010-04-01 |  |  |  |
